# B.1_project_plan

Schedule from MS Project, 2006-11-01 to 2011-11-02, A marks actual dates.

## Calendars

- Standard: Mon-Fri 08:00-12:00, 13:00-17:00; Sat-Sun off. Exceptions (off unless hours are given): 2008-11-01 08:00-12:00, 13:00-17:00, 2009-01-31 08:00-12:00, 13:00-17:00, 2009-10-31 08:00-12:00, 13:00-17:00, 2010-01-31 08:00-12:00, 13:00-17:00, 2010-07-31 08:00-12:00, 13:00-17:00, 2010-10-31 08:00-12:00, 13:00-17:00, 2011-04-30 08:00-12:00, 13:00-17:00, 2011-07-31 08:00-12:00, 13:00-17:00.

## Resources

| Resource |
| --- |
| ZLW |
| ZLW/SC |
| SC |
| WZL PS / WZL MQ / WZL TF / IPT 300 |

## Schedule

| ID | WBS | Task | Type | Duration | Start | Finish | Predecessors | Complete | Remaining | Total slack | Free slack | Constraint | Resources | Work | Actual work |
| --- | --- | --- | --- | --- | --- | --- | --- | --- | --- | --- | --- | --- | --- | --- | --- |
| 1 | 1 | Establishment of an evaluation questionnaire for B.2 |  | 66d? | 2006-11-01 A | 2007-01-31 |  | 95% | 3.3d? | 0d |  | finish no earlier than 2007-01-31 | ZLW/SC | 528h | 501.6h |
| 2 | 2 | B2 questinary | milestone | 0d | 2007-01-31 A | 2007-01-31 | 1 | 95% | 0d | 1248d |  | start no earlier than 2007-01-29 | WZL PS / WZL MQ / WZL TF / IPT 300 |  |  |
| 3 | 3 | Interviews with project partners about used simulation tools and their requirements |  | 60d? | 2007-01-31 | 2007-04-24 |  |  |  | 1189d | 0d | start no earlier than 2007-01-31 | ZLW/SC | 480h |  |
| 4 | 4 | Interviews completed | milestone | 0d | 2007-04-24 | 2007-04-24 | 3 |  |  | 1189d |  |  |  |  |  |
| 5 | 5 | Examination of the questionaire and preliminary prerequisites for the architecture |  | 100d? | 2007-03-28 | 2007-08-14 |  |  |  | 1109d | 0d | finish no earlier than 2007-08-14 | ZLW/SC | 800h |  |
| 6 | 6 | First questionnaire evaluation completed | milestone | 0d | 2007-08-14 | 2007-08-14 | 5 |  |  | 1109d |  |  |  |  |  |
| 7 | 7 | Adaptation of the first questionnaire |  | 30d | 2007-05-28 | 2007-07-06 |  |  |  | 1022d | 0d | start no earlier than 2007-05-28 | ZLW/SC | 240h |  |
| 8 | 8 | Second round of evaluation and interviews with project partners |  | 114d? | 2007-07-09 | 2007-12-13 | 7 |  |  | 1022d | 0d |  | ZLW/SC | 912h |  |
| 9 | 9 | Evaluation completed | milestone | 0d | 2007-12-13 | 2007-12-13 | 8 |  |  | 1022d |  |  |  |  |  |
| 10 | 10 | Preliminary Software architecture for WorkPackage B.2 |  | 100d? | 2007-07-16 | 2007-11-30 |  |  |  | 1031d |  | start no earlier than 2007-07-16 | ZLW | 800h |  |
| 11 | 11 | Examination of requirements for the grid architecture |  | 100d | 2007-08-15 | 2008-01-01 |  |  |  | 1009d |  | start no earlier than 2007-08-15 | SC | 800h |  |
| 12 | 12 | Categorisation of requirements of the used simulation tools |  | 70d | 2007-09-17 | 2007-12-21 |  |  |  | 1016d |  | start no earlier than 2007-09-15 | ZLW | 560h |  |
| 13 | 13 | Concepts for a generic intermediate data format and its interfacing mechanisms |  | 120d? | 2007-06-15 | 2007-11-29 |  |  |  | 1032d | 0d | start no earlier than 2007-06-15 | ZLW/SC | 960h |  |
| 14 | 14 | Definition of concepts for data format completed | milestone | 0d | 2007-11-29 | 2007-11-29 | 13 |  |  | 1032d |  |  |  |  |  |
| 15 | 15 | Research in state of the art of modeling data translators |  | 70d? | 2007-05-11 | 2007-08-16 |  |  |  | 1107d |  | start no earlier than 2007-05-11 | ZLW/SC | 560h |  |
| 16 | 16 | Preliminary work for translator using input from WorkPackage A |  | 145d? | 2007-07-16 | 2008-02-01 |  |  |  | 986d |  | start no earlier than 2007-07-16 | ZLW | 1160h |  |
| 17 | 17 | Extended data format considering input parameters and scoring functions |  | 155d? | 2007-10-01 | 2008-05-02 |  |  |  | 921d | 0d | start no earlier than 2007-10-01 | SC | 1240h |  |
| 18 | 18 | first prototype of data format | milestone | 0d | 2008-05-02 | 2008-05-02 | 17 |  |  | 921d |  |  |  |  |  |
| 19 | 19 | implementation efforts towards a first concept demonstrator / mock up |  | 180d? | 2008-01-28 | 2008-10-03 |  |  |  | 811d |  | start no earlier than 2008-01-28 |  |  |  |
| 20 | 20 | proof of concept with mock up system |  | 66d? | 2008-08-01 | 2008-10-31 |  |  |  | 791d |  | finish no earlier than 2008-10-31 |  |  |  |
| 21 | 21 | interface and data handling workshops with partners from B.2 |  | 66d? | 2008-09-01 | 2008-11-28 |  |  |  | 770d |  | start no earlier than 2008-09-01 |  |  |  |
| 22 | 22 | rudimentary implementation of adapted optimization routines using parameters and scoring mechanisms for inverse modelling |  | 64d? | 2008-10-06 | 2008-12-31 |  |  |  | 747d |  | start no earlier than 2008-10-06 |  |  |  |
| 23 | 23 | supporting end user activities for partners in B.2 regarding the coupling with the software platform from B.1 / single simulator integration |  | 132d? | 2008-10-06 | 2009-04-03 |  |  |  | 679d |  | start no earlier than 2008-10-06 |  |  |  |
| 24 | 24 | post processing and requirements for final mock up and VR Visualisation |  | 227d? | 2008-12-29 | 2009-11-06 |  |  |  | 523d |  | start no earlier than 2008-12-29 |  |  |  |
| 25 | 25 | adaptations in collaboration with B.2 |  | 162d? | 2009-06-29 | 2010-02-05 |  |  |  | 457d |  | start no earlier than 2009-06-29 |  |  |  |
| 26 | 26 | refinments in collaboration with partners from B.2 |  | 162d? | 2009-09-28 | 2010-05-07 |  |  |  | 392d |  | start no earlier than 2009-09-28 |  |  |  |
| 27 | 27 | user interface for for visualisation platfrom and steering of content management |  | 65d? | 2010-05-04 | 2010-07-31 |  |  |  | 331d |  | finish no earlier than 2010-07-31 |  |  |  |
| 28 | 28 | extended user interface for higher oder functionalities like inverse capabilities |  | 152d? | 2009-11-02 | 2010-05-31 |  |  |  | 376d |  | start no earlier than 2009-11-02 |  |  |  |
| 29 | 29 | B.2 use case driven adaptations for demonstrators |  | 202d? | 2010-05-03 | 2011-02-04 |  |  |  | 195d |  | start no earlier than 2010-05-03 |  |  |  |
| 30 | 30 | refining work concerning technology demonstrators |  | 162d? | 2010-09-27 | 2011-05-06 |  |  |  | 129d |  | start no earlier than 2010-09-27 |  |  |  |
| 31 | 31 | final demonstrator targeted implementing and testing |  | 197d? | 2011-01-31 | 2011-10-28 |  |  |  | 3d |  | start no earlier than 2011-01-31 |  |  |  |
| 32 | 32 | technology demonstrators for B | milestone | 0d | 2011-10-31 | 2011-10-31 |  |  |  | 2d |  | finish no earlier than 2011-10-31 |  |  |  |
| 33 | 33 | Definition of a holistic process map of production |  | 66d | 2006-11-01 A | 2007-01-31 |  | 95% | 3.3d | 0d |  | start no earlier than 2006-11-01 | WZL PS / WZL MQ / WZL TF / IPT 300 | 528h | 501.6h |
| 34 | 34 | Process map of production | milestone | 0d | 2007-01-31 A | 2007-01-31 | 33 | 95% | 0d | 1248d |  |  | WZL PS / WZL MQ / WZL TF / IPT 300 |  |  |
| 35 | 35 | Identification of state-of-the-art simulation models (external and within the excellence cluster) |  | 75d | 2006-12-18 | 2007-03-30 |  |  |  | 1206d | 0d | finish no earlier than 2007-03-30 | WZL PS / WZL MQ / WZL TF / IPT 300 | 600h |  |
| 36 | 36 | Process map filled with models | milestone | 0d | 2007-03-30 | 2007-03-30 | 35 |  |  | 1206d |  |  | WZL PS / WZL MQ / WZL TF / IPT 300 |  |  |
| 37 | 37 | Identification of outputs and necessary inputs for all models (from processes, from other models and from external influenes) |  | 87d | 2007-03-01 | 2007-06-29 |  |  |  | 1141d | 0d | finish no earlier than 2007-06-29 | WZL PS / WZL MQ / WZL TF / IPT 300 | 696h |  |
| 38 | 38 | Inputs and outputs for all models | milestone | 0d | 2007-06-29 | 2007-06-29 | 37 |  |  | 1141d |  |  | WZL PS / WZL MQ / WZL TF / IPT 300 |  |  |

Notes:
- 1: Questionary prototype on BSCW Server
- 33: Process map on BSCW server

| ID | WBS | Task | Type | Duration | Start | Finish | Predecessors | Total slack | Free slack | Constraint | Resources | Work |
| --- | --- | --- | --- | --- | --- | --- | --- | --- | --- | --- | --- | --- |
| 39 | 39 | **Identification of critical model parameters for stable information exchange** |  | 105d | 2007-06-18 | 2007-11-09 |  | 728d |  |  | WZL PS / WZL MQ / WZL TF / IPT 300 | 2024h |
| 40 | 39.1 | Definition of correlations between models and their in- & outputs |  | 55d | 2007-06-18 | 2007-08-31 |  | 1046d | 0d | finish no earlier than 2007-08-31 | WZL PS / WZL MQ / WZL TF / IPT 300 | 440h |
| 41 | 39.2 | Correlation matrix | milestone | 0d | 2007-08-31 | 2007-08-31 | 40 | 1046d | 0d |  | WZL PS / WZL MQ / WZL TF / IPT 300 |  |
| 42 | 39.3 | Identification of correlation gaps and deficits concerning data quality, missing correlations and missing models |  | 50d | 2007-09-03 | 2007-11-09 | 41 | 1046d | 0d | finish no earlier than 2007-10-31 | WZL PS / WZL MQ / WZL TF / IPT 300 | 400h |
| 43 | 39.4 | Gap-matrix | milestone | 0d | 2007-11-09 | 2007-11-09 | 42 | 1046d |  |  | WZL PS / WZL MQ / WZL TF / IPT 300 |  |
| 44 | 39.5 | Detailed specification of requirements for WP A.2 |  | 43d | 2007-09-03 | 2007-10-31 |  | 673d | 0d | start no earlier than 2007-09-03 | WZL PS / WZL MQ / WZL TF / IPT 300 | 344h |
| 45 | 40 | **A.2 Semantic Connectivity for specific sub-models** |  | 180d | 2007-11-01 | 2008-07-09 | 44 | 673d | 62d |  | WZL PS / WZL MQ / WZL TF / IPT 300 | 7200h |
| 46 | 40.1 | Quality, product, manufacturing process (WZL-MQ) |  | 180d | 2007-11-01 | 2008-07-09 |  | 673d |  | start no earlier than 2007-10-01 | WZL PS / WZL MQ / WZL TF / IPT 300 | 1440h |
| 47 | 40.2 | Product, manufacturing process, material (WZL-TF) |  | 180d | 2007-11-01 | 2008-07-09 |  | 673d |  | start no earlier than 2007-10-01 | WZL PS / WZL MQ / WZL TF / IPT 300 | 1440h |
| 48 | 40.3 | Logistics, factory design, product (WZL-PS) |  | 180d | 2007-11-01 | 2008-07-09 |  | 673d |  | start no earlier than 2007-10-01 | WZL PS / WZL MQ / WZL TF / IPT 300 | 1440h |
| 49 | 40.4 | Business processes, work organisation (IPT 300) |  | 180d | 2007-11-01 | 2008-07-09 |  | 673d |  | start no earlier than 2007-10-01 | WZL PS / WZL MQ / WZL TF / IPT 300 | 1440h |
| 50 | 41 | **Specification of information needs to cover the functional interdependencies** |  | 261d | 2008-10-06 | 2009-10-01 | 45 | 550d |  |  |  |  |
| 51 | 41.1 | Framework for information exchange between sub-models |  | 150d | 2008-10-06 | 2009-04-29 |  | 661d |  | start no earlier than 2008-10-06 |  |  |
| 52 | 41.2 | Criteria to ensure disjunctive transfer of information between sub-models |  | 200d | 2008-12-29 | 2009-10-01 |  | 550d |  | start no earlier than 2008-12-29 |  |  |
| 53 | 42 | Definition of necessary information flow between sub-models |  | 180d | 2009-06-29 | 2010-03-03 |  | 439d |  | start no earlier than 2009-06-29 |  |  |
| 54 | 43 | Requirements specification for translators and information models |  | 150d | 2009-09-28 | 2010-04-21 |  | 204d | 0d | start no earlier than 2009-09-28 |  |  |
| 55 | 44 | **A.3 Development of entire model map for information exchange** |  | 404d | 2010-04-22 | 2011-11-02 | 54 | 0d |  |  |  |  |
| 56 | 44.1 | Development of translators and information exchange models |  | 170d | 2010-04-22 | 2010-12-13 |  | 234d |  | start no earlier than 2009-11-02 |  |  |
| 57 | 44.2 | Information transfer functions |  | 140d | 2010-05-03 | 2010-11-10 |  | 257d |  | start no earlier than 2010-05-03 |  |  |
| 58 | 44.3 | Development of standards for an integrated quality assessment of product and manufacturing process characteristics regarding simulations as well as required supplementing information (WZL-MQ) |  | 200d | 2010-09-27 | 2011-06-29 |  | 91d |  | start no earlier than 2010-09-27 |  |  |
| 59 | 44.4 | Controlling mechanisms to ensure destinct allocation of required and perceived information between the semantic sub-models (IPT 300) |  | 200d | 2011-01-31 | 2011-11-02 |  | 0d |  | start no earlier than 2011-01-31 |  |  |
